# IWCF_MSProj_Rev1

Schedule from MS Project, 2001-09-04 to 2002-01-18, costs in $.
RPC, Inc.

## Calendars

- Standard: Mon-Fri 08:00-12:00, 13:00-17:00; Sat-Sun off. Exceptions (off unless hours are given): 2001-11-22 to 2001-11-23, 2001-12-24 to 2001-12-25.

## Resources

| Resource | Rate |
| --- | --- |
| Rhonda Cohen | 15360000 |
| Peter Simon | 93.75 |
| Clare Tullier | 87.5 |
| Mary DeCarlo | 40.62 |
| Steve Salis | 62.5 |
| Gwen Iselt | 62.5 |
| Jennifer Iselt | 12.5 |
| Admin Assistant | 21.88 |
| James Ivey | 37.5 |
| Robbie Fletcher | 62.5 |
| Ken Purcell | 56.25 |
| Dave Salonius | 43.75 |
| Metric consultant | 43.75 |
| Omni International |  |
| Changent Spanish Interpreter | 31.25 |
| Nuggeteer | 25 |
| Bilingual tester 1 | 31.25 |
| Rich DeBuys | 62.5 |
| Spanish speaking SME | 31.25 |
| Nuggeteer 2 | 25 |
| Nuggeteer 1 | 25 |
| Bilingual Tester 2 | 31.25 |
| Nuggeteer 3 | 25 |
| Spanish speaking SME | 31.25 |
| Nuggeteer 4 | 25 |
| Bilingual Tester 3 | 31.25 |
| Admin Assistant 1 | 21.88 |
| Admin Assistant 2 | 21.88 |
| Changent Spanish Interpreter 1 | 31.25 |
| Changent Spanish Interpreter 2 | 31.25 |
| EQ Sim programmers | 37.5 |
| Kameya Muteba | 20 |
| PR Sim programmers | 37.5 |
| CM Sim programmers | 37.5 |
| Writer 1 | 37.5 |
| Writer 2 | 37.5 |
| SME 1 | 62.5 |
| SME 2 | 62.5 |
| Producer 1 | 62.5 |
| Brian Payne | 52.5 |
| Graphic Artist 1 | 43.75 |
| Star Team Gatekeeper | 43.75 |
| Shooter 1 | 62.5 |
| Editor | 43.75 |
| Phil Palmer | 43.75 |
| Alan Ackles | 250 |
| Carolyn McOrmack | 250 |
| Nuggeteer Fixer | 43.75 |
| Tester 1 | 31.25 |
| Tester2 | 31.25 |
| Tester 2 | 31.25 |
| Bilingual SME | 43.75 |
| SME2 | 62.5 |
| Fixed Cost (3 days work) |  |
| Nuggeteer Fixer 1 |  |
| Nuggeteer Fixer 2 |  |
| Steve Salisl |  |
| X Factor |  |
| WCS |  |
| Chris Klee |  |
| Russell Blair |  |
| CT/SN SME |  |
| Tim Jones |  |
| Spanish SME |  |
| S. Salis |  |
| R. Cohen |  |
| C. Tullier |  |
| R. Fletcher |  |
| M. DeCarlo |  |
| K. Purcell |  |
| D. Salonius |  |
| Core team |  |
| Nuggeteer 2 |  |

## Schedule

| ID | WBS | Task | Duration | Start | Finish | Predecessors | Total slack | Free slack | Constraint | Resources | Work | Cost |
| --- | --- | --- | --- | --- | --- | --- | --- | --- | --- | --- | --- | --- |
| 1 | 1 | **IWCF** | 95d | 2001-09-04 | 2002-01-18 |  | 0d |  |  |  | 4757h | 196,298.75 |
| 2 | 1.1 | **Add IWCF Content to System 21** | 95d | 2001-09-04 | 2002-01-18 |  | 0d |  |  |  | 4757h | 196,298.75 |
| 3 | 1.1.1 | Identify IWCF vs. IADC and MMS requirement gaps | 5d | 2001-09-04 | 2001-09-10 |  | 0d |  |  | Steve Salis; Admin Assistant | 80h | 3,375 |
| 4 | 1.1.2 | Establish design for IWCF content | 3d | 2001-09-25 | 2001-09-27 | 3FS+10d | 0d |  |  | Steve Salis; Producer 1 | 48h | 3,000 |
| 5 | 1.1.3 | Acquire content resources | 3d | 2001-10-05 | 2001-10-09 | 4FS+5d | 0d |  |  | Steve Salis; Producer 1 | 48h | 3,000 |
| 6 | 1.1.4 | Write nugget scripts to fill requirement gaps/include metric | 15d | 2001-10-10 | 2001-10-30 | 5 | 0d |  |  | Steve Salis; Writer 1; Writer 2 | 360h | 16,500 |
| 7 | 1.1.5 | SMEs review scripts | 3d | 2001-10-17 | 2001-10-19 | 6SS+5d | 0d |  | start no earlier than 2001-05-21 | SME 1; SME 2 | 48h | 3,000 |
| 8 | 1.1.6 | Enter SME script revisions | 3d | 2001-10-19 | 2001-10-23 | 7SS+2d | 0d |  | start no earlier than 2001-05-23 | Writer 1; Writer 2 | 48h | 1,800 |
| 9 | 1.1.7 | SME final script review | 2.5d | 2001-10-23 | 2001-10-25 | 8SS+2d | 0d |  | start no earlier than 2001-05-28 | SME 1; SME 2 | 40h | 2,500 |
| 10 | 1.1.8 | Enter final SME 1 & 2 script revisions | 3d | 2001-10-25 | 2001-10-29 | 9SS+2d | 0d |  | start no earlier than 2001-05-30 | Admin Assistant | 24h | 525 |
| 11 | 1.1.9 | Produce storyboards | 8d | 2001-10-29 | 2001-11-07 | 10SS+2d | 4d | 0d | start no earlier than 2001-06-04 | Steve Salis; Producer 1 | 128h | 8,000 |
| 12 | 1.1.10 | SMEs review storyboards | 2.5d | 2001-11-01 | 2001-11-05 | 11SS+3d | 4d | 0d | start no earlier than 2001-06-11 | SME 1; SME 2 | 40h | 2,500 |
| 13 | 1.1.11 | Incorporate SME revisions into storyboards | 3d | 2001-11-05 | 2001-11-07 | 12SS+2d | 4d | 0d | start no earlier than 2001-06-14 | Steve Salis; Producer 1 | 48h | 3,000 |
| 14 | 1.1.12 | SME final storyboard review | 2d | 2001-11-08 | 2001-11-09 | 13SS+3d | 89d | 0d | start no earlier than 2001-06-18 | SME 1; SME 2 | 32h | 2,000 |
| 15 | 1.1.13 | Incorporate final SME storyboard revisions | 3d | 2001-11-12 | 2001-11-14 | 14SS+2d | 89d |  | start no earlier than 2001-06-21 | Steve Salis; Producer 1 | 48h | 3,000 |
| 16 | 1.1.14 | **Produce assets** | 28d | 2001-10-30 | 2001-12-10 |  | 0d |  |  |  | 1697h | 91,823.75 |
| 17 | 1.1.14.1 | **Graphics** | 21d | 2001-11-08 | 2001-12-10 |  | 4d |  |  |  | 1304h | 72,380 |
| 18 | 1.1.14.1.1 | Create graphics from storyboards | 20d | 2001-11-08 | 2001-12-07 | 13SS+3d | 4d | 0d | start no earlier than 2001-06-27 | Brian Payne; Graphic Artist 1 | 320h | 15,400 |
| 19 | 1.1.14.1.2 | SME 1/Salis review graphics | 10d | 2001-11-15 | 2001-11-30 | 18SS+5d | 4d | 0d | start no earlier than 2001-07-02 | SME 1; Steve Salis | 160h | 10,000 |
| 20 | 1.1.14.1.3 | SME 2/Producer 1 review graphics | 10d | 2001-11-15 | 2001-11-30 | 18SS+5d | 4d | 0d |  |  |  |  |
| 21 | 1.1.14.1.4 | Revise graphics | 12d | 2001-11-19 | 2001-12-06 | 19SS+2d, 20SS+2d | 4d | 0d |  | Brian Payne; Graphic Artist 1 | 192h | 9,240 |
| 22 | 1.1.14.1.5 | SME 1/Salis review revised graphics | 10d | 2001-11-26 | 2001-12-07 | 21SS+3d | 73d | 0d |  | SME 1; Steve Salis | 160h | 10,000 |
| 23 | 1.1.14.1.6 | SME 2/Producer 1 review revised graphics | 10d | 2001-11-26 | 2001-12-07 | 21SS+3d | 73d | 0d | start no earlier than 2001-07-30 | SME 2; Producer 1 | 160h | 10,000 |
| 24 | 1.1.14.1.7 | Make final graphics revisions | 7d | 2001-11-28 | 2001-12-06 | 22SS+2d, 23SS+2d | 73d | 0d | start no earlier than 2001-08-03 | Brian Payne; Graphic Artist 1 | 112h | 5,390 |
| 25 | 1.1.14.1.8 | SME 1/Salis graphics approval | 6d | 2001-11-30 | 2001-12-07 | 24SS+2d | 73d | 0d | start no earlier than 2001-08-07 | SME 1; Steve Salis | 96h | 6,000 |
| 26 | 1.1.14.1.9 | SME 2/Producer 1 graphics approval | 6d | 2001-11-30 | 2001-12-07 | 24SS+2d | 73d | 0d |  | SME 2; Producer 1 | 96h | 6,000 |
| 27 | 1.1.14.1.10 | Enter final graphics into Star Team | 1d | 2001-12-10 | 2001-12-10 | 26, 25 | 73d |  |  | Star Team Gatekeeper | 8h | 350 |

Notes:
- 2: Dual record metric/field units when producing IWCF (English) material.

| ID | WBS | Task | Duration | Start | Finish | Predecessors | Total slack | Free slack | Constraint | Resources | Work | Cost |
| --- | --- | --- | --- | --- | --- | --- | --- | --- | --- | --- | --- | --- |
| 28 | 1.1.14.2 | **Video** | 21d | 2001-10-30 | 2001-11-29 |  | 0d |  |  |  | 192h | 7,300 |
| 29 | 1.1.14.2.1 | Pre-production | 10d | 2001-10-30 | 2001-11-12 | 10 | 0d |  | start no earlier than 2001-06-18 | Fixed Cost (3 days work) | 80h | 1,500 |
| 30 | 1.1.14.2.2 | Shoot | 3d | 2001-11-13 | 2001-11-15 | 29 | 0d |  | start no earlier than 2001-06-27 | Steve Salis; Shooter 1 | 48h | 3,000 |
| 31 | 1.1.14.2.3 | Post production | 7d | 2001-11-16 | 2001-11-28 | 30 | 0d |  |  | Editor | 56h | 2,450 |
| 32 | 1.1.14.2.4 | Compression | 0.5d | 2001-11-29 | 2001-11-29 | 31 | 0d |  |  | Editor | 4h | 175 |
| 33 | 1.1.14.2.5 | Enter video assets into Star Team | 0.5d | 2001-11-29 | 2001-11-29 | 32 | 0d |  |  | Star Team Gatekeeper | 4h | 175 |
| 34 | 1.1.14.3 | **Narration** | 3.12d | 2001-10-30 | 2001-11-02 |  | 17.88d |  |  |  | 33h | 3,093.75 |
| 35 | 1.1.14.3.1 | Record narration | 1d | 2001-10-30 | 2001-10-30 | 10 | 17.88d | 0d | start no earlier than 2001-06-11 | Phil Palmer; Alan Ackles | 16h | 2,350 |
| 36 | 1.1.14.3.2 | Edit narration | 2d | 2001-10-31 | 2001-11-01 | 35 | 17.88d | 0d |  | Phil Palmer | 16h | 700 |
| 37 | 1.1.14.3.3 | Enter into Star Team/Link | 1h | 2001-11-02 | 2001-11-02 | 36 | 17.88d |  |  | Star Team Gatekeeper | 1h | 43.75 |
| 38 | 1.1.14.4 | **Questions** | 14d | 2001-10-30 | 2001-11-16 |  | 41d |  |  |  | 168h | 9,050 |
| 39 | 1.1.14.4.1 | Write questions to requirements/nuggets | 3d | 2001-10-30 | 2001-11-01 | 10 | 25d | 0d | start no earlier than 2001-06-11 | Writer 1; Writer 2 | 48h | 1,800 |
| 40 | 1.1.14.4.2 | SME review questions | 2d | 2001-11-02 | 2001-11-05 | 39 | 25d | 0d | start no earlier than 2001-06-14 | SME 1; SME 2 | 32h | 2,000 |
| 41 | 1.1.14.4.3 | Enter SME question revisions | 1d | 2001-11-06 | 2001-11-06 | 40 | 25d | 0d | start no earlier than 2001-06-18 | Admin Assistant | 8h | 175 |
| 42 | 1.1.14.4.4 | SME final question review | 1d | 2001-11-07 | 2001-11-07 | 41 | 25d | 0d |  | SME 1; SME 2 | 16h | 1,000 |
| 43 | 1.1.14.4.5 | Enter final SME question revisions | 1d | 2001-11-08 | 2001-11-08 | 42 | 25d | 0d |  | Admin Assistant | 8h | 175 |
| 44 | 1.1.14.4.6 | Record question audio | 1d | 2001-11-09 | 2001-11-09 | 43 | 25d | 0d |  | Phil Palmer; Carolyn McOrmack | 16h | 2,350 |
| 45 | 1.1.14.4.7 | Edit question audio | 2d | 2001-11-12 | 2001-11-13 | 44 | 25d | 0d |  | Phil Palmer | 16h | 700 |
| 46 | 1.1.14.4.8 | Enter into Star Team/Link | 0.5d | 2001-11-14 | 2001-11-14 | 45 | 25d | 0d |  | Star Team Gatekeeper | 4h | 175 |
| 47 | 1.1.14.4.9 | Migrate question databases/audio to God Box | 0.5d | 2001-11-14 | 2001-11-14 | 46 | 25d | 0d |  | Star Team Gatekeeper | 4h | 175 |
| 48 | 1.1.14.4.10 | Test questions, revise as necessary | 2d | 2001-11-15 | 2001-11-16 | 47 | 25d |  |  | Tester 1 | 16h | 500 |
| 49 | 1.1.15 | **Produce nuggets** | 34d | 2001-11-30 | 2002-01-18 |  | 0d |  |  |  | 2068h | 52,275 |
| 50 | 1.1.15.1 | Create nuggets | 20d | 2001-11-30 | 2001-12-31 | 37, 28, 21SS+3d | 0d |  | start no earlier than 2001-07-13 | Nuggeteer 1; Nuggeteer 2; Nuggeteer 3 | 480h | 12,000 |
| 51 | 1.1.15.2 | Review nuggets 1 | 1d | 2001-12-05 | 2001-12-05 | 50SS+3d | 76d |  | start no earlier than 2001-07-23 | SME 1; Steve Salis; Nuggeteer Fixer 1 | 24h | 1,000 |
| 52 | 1.1.15.3 | Review nuggets 1 | 1d | 2001-12-05 | 2001-12-05 | 50SS+3d | 4d | 0d |  | SME 2; Producer 1; Nuggeteer Fixer 2 | 24h | 1,000 |
| 53 | 1.1.15.4 | Make nuggets 1 revisions | 3d | 2001-12-06 | 2001-12-10 | 52 | 4d | 0d | start no earlier than 2001-07-25 | Nuggeteer Fixer 1; Nuggeteer Fixer 2 | 48h |  |
| 54 | 1.1.15.5 | Final nuggets 1 review | 1d | 2001-12-11 | 2001-12-11 | 53 | 72d |  | start no earlier than 2001-07-30 | SME 1; Steve Salis; Nuggeteer Fixer 1 | 24h | 1,000 |
| 55 | 1.1.15.6 | Final nuggets 1 review | 1d | 2001-12-11 | 2001-12-11 | 53 | 4d | 0d |  | SME 2; Producer 1; Nuggeteer Fixer 2 | 24h | 1,000 |
| 56 | 1.1.15.7 | Make final nuggets 1 revisions | 3d | 2001-12-12 | 2001-12-14 | 55 | 4d | 0d | start no earlier than 2001-07-31 | Nuggeteer Fixer 1; Nuggeteer Fixer 2 | 48h |  |
| 57 | 1.1.15.8 | SMEs/Producers approve nuggets 1 | 1d | 2001-12-17 | 2001-12-17 | 56 | 16d | 0d |  | SME 1; SME 2; Steve Salis; Nuggeteer Fixer 1; Producer 1 | 40h | 2,000 |
| 58 | 1.1.15.9 | Edit Master Syllabus nuggets 1 | 0.5d | 2001-12-18 | 2001-12-18 | 57 | 16d | 0d |  | Steve Salis; Producer 1 | 8h | 500 |
| 59 | 1.1.15.10 | Enter nuggets 1 into Star Team, migrate to God Box | 0.5d | 2001-12-18 | 2001-12-18 | 58 | 16d | 0d |  | Star Team Gatekeeper | 4h | 175 |
| 60 | 1.1.15.11 | Test nuggets 1 on God Box | 2d | 2001-12-19 | 2001-12-20 | 59 | 16d | 0d |  | Tester 1; Tester2 | 32h | 1,000 |
| 61 | 1.1.15.12 | Revise nuggets 1 as necessary | 2d | 2001-12-21 | 2001-12-26 | 60 | 16d | 0d | start no earlier than 2001-08-15 | Nuggeteer Fixer 1; Nuggeteer Fixer 2 | 32h |  |
| 62 | 1.1.15.13 | Verify nuggets 1 functional on God Box | 1d | 2001-12-27 | 2001-12-27 | 61 | 16d |  |  | Tester 1; Tester 2 | 16h | 500 |
| 63 | 1.1.15.14 | Review Nuggets 2 | 1d | 2001-12-10 | 2001-12-10 | 50SS+6d | 73d |  |  | SME 1; Steve Salis; Nuggeteer Fixer 1 | 24h | 1,000 |
| 64 | 1.1.15.15 | Review Nuggets 2 | 1d | 2001-12-10 | 2001-12-10 | 50SS+6d | 54d | 4d |  | SME 2; Producer 1; Nuggeteer Fixer 2 | 24h | 1,000 |
| 65 | 1.1.15.16 | Make nuggets 2 revisions | 3d | 2001-12-17 | 2001-12-19 | 64, 56 | 50d | 0d |  | Nuggeteer Fixer 2; Nuggeteer Fixer 1 | 48h |  |
| 66 | 1.1.15.17 | Final nuggets 2 review | 1d | 2001-12-20 | 2001-12-20 | 65 | 65d |  |  | SME 1; Steve Salis; Nuggeteer Fixer 1 | 24h | 1,000 |
| 67 | 1.1.15.18 | Final nuggets 2 review | 1d | 2001-12-20 | 2001-12-20 | 65 | 56d | 0d |  | SME 2; Producer 1; Nuggeteer Fixer 2 | 24h | 1,000 |
| 68 | 1.1.15.19 | Make final nuggets 2 revisions | 3d | 2001-12-21 | 2001-12-27 | 67 | 56d | 0d |  | Nuggeteer Fixer 1; Nuggeteer Fixer 2 | 48h |  |
| 69 | 1.1.15.20 | SMEs/Producers approve nuggets 2 | 1d | 2001-12-28 | 2001-12-28 | 68 | 56d | 0d |  | SME 1; SME 2; Steve Salis; Producer 1; Nuggeteer 2; Nuggeteer 1 | 48h | 2,400 |
| 70 | 1.1.15.21 | Edit Master Syllabus nuggets 2 | 0.5d | 2001-12-31 | 2001-12-31 | 69 | 56d | 0d |  | Steve Salis; Producer 1 | 8h | 500 |
| 71 | 1.1.15.22 | Enter nuggets 2 into Star Team, migrate to God Box | 0.5d | 2001-12-31 | 2001-12-31 | 70 | 56d | 0d |  | Star Team Gatekeeper | 4h | 175 |
| 72 | 1.1.15.23 | Test nuggets 2 on God Box | 1d | 2002-01-01 | 2002-01-01 | 71 | 56d | 0d |  | Tester 1; Tester 2 | 16h | 500 |
| 73 | 1.1.15.24 | Revise nuggets 2 as necessary | 2d | 2002-01-02 | 2002-01-03 | 72 | 56d | 0d |  | Nuggeteer Fixer 1; Nuggeteer Fixer 2 | 32h |  |
| 74 | 1.1.15.25 | Verify nuggets 2 functional on God Box | 1d | 2002-01-04 | 2002-01-04 | 73 | 56d |  |  | Tester 1; Tester 2 | 16h | 500 |
| 75 | 1.1.15.26 | Review Nuggets 3 | 1d | 2001-12-14 | 2001-12-14 | 50SS+10d | 69d |  |  | SME 1; Steve Salis; Nuggeteer Fixer 1 | 24h | 1,000 |
| 76 | 1.1.15.27 | Review Nuggets 3 | 1d | 2001-12-14 | 2001-12-14 | 50SS+10d | 53d | 3d |  | SME 2; Producer 1; Nuggeteer Fixer 2 | 24h | 1,000 |
| 77 | 1.1.15.28 | Make nuggets 3 revisions | 3d | 2001-12-20 | 2001-12-26 | 76, 65 | 50d | 0d |  | Nuggeteer Fixer 2; Nuggeteer Fixer 1 | 48h |  |
| 78 | 1.1.15.29 | Final nuggets 3 review | 1d | 2001-12-27 | 2001-12-27 | 77 | 62d |  |  | SME 1; Steve Salis; Nuggeteer Fixer 1 | 24h | 1,000 |
| 79 | 1.1.15.30 | Final nuggets 3 review | 1d | 2001-12-27 | 2001-12-27 | 77 | 53d | 0d |  | SME 2; Producer 1; Nuggeteer Fixer 2 | 24h | 1,000 |
| 80 | 1.1.15.31 | Make final nuggets 3 revisions | 3d | 2001-12-28 | 2002-01-01 | 79 | 53d | 0d |  | Nuggeteer Fixer 1; Nuggeteer Fixer 2 | 48h |  |
| 81 | 1.1.15.32 | SMEs/Producers approve nuggets 3 | 1d | 2002-01-02 | 2002-01-02 | 80 | 53d | 0d |  | SME 1; SME 2; Steve Salis; Producer 1; Nuggeteer 2; Nuggeteer 1 | 48h | 2,400 |
| 82 | 1.1.15.33 | Edit Master Syllabus nuggets 3 | 0.5d | 2002-01-03 | 2002-01-03 | 81 | 53d | 0d |  | Steve Salis; Producer 1 | 8h | 500 |
| 83 | 1.1.15.34 | Enter nuggets 3 into Star Team, migrate to God Box | 0.5d | 2002-01-03 | 2002-01-03 | 82 | 53d | 0d |  | Star Team Gatekeeper | 4h | 175 |
| 84 | 1.1.15.35 | Test nuggets 3 on God Box | 1d | 2002-01-04 | 2002-01-04 | 83 | 53d | 0d |  | Tester 1; Tester 2 | 16h | 500 |
| 85 | 1.1.15.36 | Revise nuggets 3 as necessary | 2d | 2002-01-07 | 2002-01-08 | 84 | 53d | 0d |  | Nuggeteer Fixer 1; Nuggeteer Fixer 2 | 32h |  |
| 86 | 1.1.15.37 | Verify nuggets 3 functional on God Box | 1d | 2002-01-09 | 2002-01-09 | 85 | 53d |  |  | Tester 1; Tester 2 | 16h | 500 |
| 87 | 1.1.15.38 | Review Nuggets 4 | 1d | 2001-12-21 | 2001-12-21 | 50SS+15d | 64d |  |  | SME 1; Steve Salis; Nuggeteer Fixer 1 | 24h | 1,000 |
| 88 | 1.1.15.39 | Review Nuggets 4 | 1d | 2001-12-21 | 2001-12-21 | 50SS+15d | 51d | 1d |  | SME 2; Producer 1; Nuggeteer Fixer 2 | 24h | 1,000 |
| 89 | 1.1.15.40 | Make nuggets 4 revisions | 3d | 2001-12-27 | 2001-12-31 | 88, 77 | 50d | 0d |  | Nuggeteer Fixer 2; Nuggeteer Fixer 1 | 48h |  |
| 90 | 1.1.15.41 | Final nuggets 4 review | 1d | 2002-01-01 | 2002-01-01 | 89 | 59d |  |  | SME 1; Steve Salis; Nuggeteer Fixer 1 | 24h | 1,000 |
| 91 | 1.1.15.42 | Final nuggets 4 review | 1d | 2002-01-01 | 2002-01-01 | 89 | 50d | 0d |  | SME 2; Producer 1; Nuggeteer Fixer 2 | 24h | 1,000 |
| 92 | 1.1.15.43 | Make final nuggets 4 revisions | 3d | 2002-01-02 | 2002-01-04 | 91 | 50d | 0d |  | Nuggeteer Fixer 1; Nuggeteer Fixer 2 | 48h |  |
| 93 | 1.1.15.44 | SMEs/Producers approve nuggets 4 | 1d | 2002-01-07 | 2002-01-07 | 92 | 50d | 0d |  | SME 1; SME 2; Steve Salis; Producer 1; Nuggeteer 2; Nuggeteer 1 | 48h | 2,200 |
| 94 | 1.1.15.45 | Edit Master Syllabus nuggets 4 | 0.5d | 2002-01-08 | 2002-01-08 | 93 | 50d | 0d |  | Steve Salis; Producer 1 | 8h | 500 |
| 95 | 1.1.15.46 | Enter nuggets 4 into Star Team, migrate to God Box | 0.5d | 2002-01-08 | 2002-01-08 | 94 | 50d | 0d |  | Star Team Gatekeeper | 4h | 175 |
| 96 | 1.1.15.47 | Test nuggets 4 on God Box | 1d | 2002-01-09 | 2002-01-09 | 95 | 50d | 0d |  | Tester 1; Tester 2 | 16h | 500 |
| 97 | 1.1.15.48 | Revise nuggets 4 as necessary | 2d | 2002-01-10 | 2002-01-11 | 96 | 50d | 0d |  | Nuggeteer Fixer 1; Nuggeteer Fixer 2 | 32h |  |

| ID | WBS | Task | Duration | Start | Finish | Predecessors | Total slack | Resources | Work | Cost |
| --- | --- | --- | --- | --- | --- | --- | --- | --- | --- | --- |
| 98 | 1.1.15.49 | Verify nuggets 4 functional on God Box | 1d | 2002-01-14 | 2002-01-14 | 97 | 50d | Tester 1; Tester 2 | 16h | 500 |
| 99 | 1.1.15.50 | Review Nuggets 5 | 1d | 2002-01-01 | 2002-01-01 | 50SS+20d | 59d | SME 1; Steve Salis; Nuggeteer Fixer 1 | 24h | 1,000 |
| 100 | 1.1.15.51 | Review Nuggets 5 | 1d | 2002-01-01 | 2002-01-01 | 50SS+20d | 0d | SME 2; Producer 1; Nuggeteer Fixer 2 | 24h | 1,000 |
| 101 | 1.1.15.52 | Make nuggets 5 revisions | 3d | 2002-01-02 | 2002-01-04 | 100 | 0d | Nuggeteer Fixer 2; Nuggeteer Fixer 1 | 48h |  |
| 102 | 1.1.15.53 | Final nuggets 5 review | 1d | 2002-01-07 | 2002-01-07 | 101 | 55d | SME 1; Steve Salis; Nuggeteer Fixer 1 | 24h | 1,000 |
| 103 | 1.1.15.54 | Final nuggets 5 review | 1d | 2002-01-07 | 2002-01-07 | 101 | 0d | SME 2; Producer 1; Nuggeteer Fixer 2 | 24h | 1,000 |
| 104 | 1.1.15.55 | Make final nuggets 5 revisions | 3d | 2002-01-08 | 2002-01-10 | 103 | 0d | Nuggeteer Fixer 1; Nuggeteer Fixer 2 | 48h |  |
| 105 | 1.1.15.56 | SMEs/Producers approve nuggets 5 | 1d | 2002-01-11 | 2002-01-11 | 104 | 0d | SME 1; SME 2; Steve Salis; Producer 1; Nuggeteer 2; Nuggeteer 1 | 48h | 2,400 |
| 106 | 1.1.15.57 | Edit Master Syllabus nuggets 5 | 0.5d | 2002-01-14 | 2002-01-14 | 105 | 0d | Steve Salis; Producer 1 | 8h | 500 |
| 107 | 1.1.15.58 | Enter nuggets 5 into Star Team, migrate to God Box | 0.5d | 2002-01-14 | 2002-01-14 | 106 | 0d | Star Team Gatekeeper | 4h | 175 |
| 108 | 1.1.15.59 | Test nuggets 5 on God Box | 1d | 2002-01-15 | 2002-01-15 | 107 | 0d | Tester 1; Tester 2 | 16h | 500 |
| 109 | 1.1.15.60 | Revise nuggets 5 as necessary | 2d | 2002-01-16 | 2002-01-17 | 108 | 0d | Nuggeteer Fixer 1; Nuggeteer Fixer 2 | 32h |  |
| 110 | 1.1.15.61 | Verify nuggets 5 functional on God Box | 1d | 2002-01-18 | 2002-01-18 | 109 | 0d | Tester 1; Tester 2 | 16h | 500 |
